# Binak Oilfiield Development,New Gas Commpressor Station

Schedule from MS Project, 2024-02-12 to 2025-08-13, status date 2024-09-28, A marks actual dates.

## Calendars

- Standard: Mon-Tue 07:00-16:00; Wed 07:00-15:00; Thu-Fri off; Sat-Sun 07:00-16:00. Exceptions (off unless hours are given): 2025-06-20 08:00-12:00, 13:00-17:00.

## Schedule

| ID | WBS | Task | Type | Duration | Start | Finish | Predecessors | Complete | Remaining | Total slack | Free slack | Constraint | Start Date | Finish Date |
| --- | --- | --- | --- | --- | --- | --- | --- | --- | --- | --- | --- | --- | --- | --- |
| 1 | 1 | **project Air Cooler(Binak Oilfield Development , New Gas Commpressor Station)** |  | 432.25d | 2024-02-12 A | 2025-08-13 |  | 10% | 390.14d | 0d |  |  | 102/11/23 | 104/5/22 |
| 2 | 1.1 | **Milestones** |  | 432.25d | 2024-02-12 A | 2025-08-13 |  |  | 432.25d | 0d |  |  | 102/11/23 | 104/5/22 |
| 3 | 1.1.1 | Project start | milestone | 0d | 2024-02-12 A | 2024-02-12 A | 4 | 100% |  |  |  |  | 102/11/23 | 102/11/23 |
| 4 | 1.1.2 | 1St payment 15% (Adv. Payment) | milestone | 0d | 2024-02-12 A | 2024-02-12 A |  | 100% |  |  |  |  | 102/11/23 | 102/11/23 |
| 5 | 1.1.3 | 2nd payment 5% (Against Submission Of GA Drawing) | milestone | 0d | 2024-09-28 | 2024-09-28 |  |  |  | 252d |  | start no earlier than 2024-09-28 | 103/7/7 | 103/7/7 |
| 6 | 1.1.4 | 3rd payment 40% (Againt Unpriced Proforma Invoice Of Main Raw Material(Plate & Tube)) | milestone | 0d | 2024-10-23 | 2024-10-23 | 21, 22, 40, 44 |  |  | 232d |  | start no earlier than 2024-09-28 | 103/8/2 | 103/8/2 |
| 7 | 1.1.5 | 4rd payment 15% (Against Submission Main Raw Material IRN At Material Vendor,s Shop) | milestone | 0d | 2025-05-25 | 2025-05-25 | 26SS, 42SS, 46SS |  |  | 64d |  |  | 104/3/4 | 104/3/4 |
| 8 | 1.1.6 | 5rd payment 20% (Against Submission Of Shipping Document) | milestone | 0d | 2025-07-30 | 2025-07-30 | 155SS, 156SS, 157, 158SS, 160SS, 161SS, 162SS, 163SS |  |  | 11d |  |  | 104/5/8 | 104/5/8 |
| 9 | 1.1.7 | 6rd payment 5% (Against Final Data Book) | milestone | 0d | 2025-08-05 | 2025-08-05 | 166SS |  |  | 6d |  |  | 104/5/14 | 104/5/14 |
| 10 | 1.1.8 | Project finish | milestone | 0d | 2025-08-13 | 2025-08-13 | 166 |  |  | 0d |  |  | 104/5/22 | 104/5/22 |
| 11 | 1.2 | **Engineering** |  | 316.05d | 2024-02-12 A | 2025-03-19 |  | 27% | 230.7d | 116.2d |  |  | 102/11/23 | 103/12/29 |
| 12 | 1.2.1 | process |  | 65d | 2024-02-13 A | 2024-10-14 A | 16SS+1d | 100% |  |  |  |  | 102/11/24 | 103/7/23 |
| 13 | 1.2.2 | Mechanical |  | 140d | 2024-02-26 A | 2025-03-19 | 12SS+10d | 3% | 135.8d | 6.2d | 0d |  | 102/12/7 | 103/12/29 |
| 14 | 1.2.3 | Electrical & Instrument |  | 90d | 2024-03-10 A | 2025-01-08 | 12SS+10d, 13SS+10d | 10% | 81d | 6d | 0d |  | 102/12/20 | 103/10/19 |
| 15 | 1.2.4 | Civil & Structure |  | 95d | 2024-03-23 A | 2024-12-09 | 13SS+20d | 40% | 57d | 95d | 34.25d |  | 103/1/4 | 103/9/19 |
| 16 | 1.2.5 | General |  | 126d | 2024-02-12 A | 2025-01-25 | 3 | 26% | 93.24d | 158.76d | 1d |  | 102/11/23 | 103/11/6 |
| 17 | 1.2.6 | Material |  | 60d | 2024-04-16 A | 2024-11-20 | 12SS+50d, 16SS+50d | 30% | 42d | 210d |  |  | 103/1/28 | 103/8/30 |
| 18 | 1.2.7 | QC |  | 60d | 2024-04-16 A | 2024-12-08 | 13SS+40d | 8% | 55.2d | 196.8d |  |  | 103/1/28 | 103/9/18 |
| 19 | 1.3 | **Raw Material/Supply** |  | 360.25d | 2024-04-29 A | 2025-07-30 |  | 7% | 335.42d | 6d |  |  | 103/2/10 | 104/5/8 |
| 20 | 1.3.1 | **Plates For Header Box** |  | 322.25d | 2024-04-29 A | 2025-06-14 |  | 9% | 294.67d | 0d |  |  | 103/2/10 | 104/3/24 |
| 21 | 1.3.1.1 | Inquiry for Plates For Header Box |  | 19d | 2024-04-29 A | 2024-05-22 A | 13SS+50d | 100% |  |  |  |  | 103/2/10 | 103/3/2 |
| 22 | 1.3.1.2 | Po Placement for Plates For Header Box |  | 20d | 2024-09-29 | 2024-10-23 | 21 |  |  | 0d |  | start no earlier than 2024-09-28 | 103/7/8 | 103/8/2 |
| 23 | 1.3.1.3 | Fabrication for Plates For Header Box |  | 108d | 2024-10-23 | 2025-03-10 | 22 |  |  | 0d |  | start no earlier than 2024-09-28 | 103/8/2 | 103/12/20 |
| 24 | 1.3.1.4 | Shipping for Plates For Header Box |  | 30d | 2025-03-10 | 2025-04-16 | 23 |  |  | 0d |  |  | 103/12/20 | 104/1/27 |
| 25 | 1.3.1.5 | Custom Clearance for Plates For Header Box |  | 30d | 2025-04-16 | 2025-05-25 | 24 |  |  | 0d |  |  | 104/1/27 | 104/3/4 |
| 26 | 1.3.1.6 | Deliver to Vendor ShopPlates For Header Box |  | 15d | 2025-05-25 | 2025-06-14 | 25 |  |  | 0d |  |  | 104/3/4 | 104/3/24 |

| ID | WBS | Task | Duration | Start | Finish | Predecessors | Complete | Total slack | Free slack | Constraint | Start Date | Finish Date |
| --- | --- | --- | --- | --- | --- | --- | --- | --- | --- | --- | --- | --- |
| 27 | 1.3.2 | **Flange - Flange Gasket** | 160d | 2024-09-29 | 2025-04-20 |  |  | 51d |  |  | 103/7/8 | 104/1/31 |
| 28 | 1.3.2.1 | Po Placement for Flange - Flange Gasket | 20d | 2024-09-29 | 2024-10-23 | 13SS+60d |  | 51d | 0d | start no earlier than 2024-09-28 | 103/7/8 | 103/8/2 |
| 29 | 1.3.2.2 | Fabrication for Flange - Flange Gasket | 120d | 2024-10-23 | 2025-03-25 | 28 |  | 51d | 0d | start no earlier than 2024-09-28 | 103/8/2 | 104/1/5 |
| 30 | 1.3.2.3 | Deliver to Vendor ShopFlange - Flange Gasket | 20d | 2025-03-25 | 2025-04-20 | 29 |  | 51d |  |  | 104/1/5 | 104/1/31 |
| 31 | 1.3.3 | **Nozzle Pipe/Transition Nozzle** | 160d | 2024-09-29 | 2025-04-20 |  |  | 43d |  |  | 103/7/8 | 104/1/31 |
| 32 | 1.3.3.1 | Po Placement for Nozzle Pipe/Transition Nozzle | 20d | 2024-09-29 | 2024-10-23 | 13SS+60d |  | 43d | 0d | start no earlier than 2024-09-28 | 103/7/8 | 103/8/2 |
| 33 | 1.3.3.2 | Fabrication for Nozzle Pipe/Transition Nozzle | 120d | 2024-10-23 | 2025-03-25 | 32 |  | 43d | 0d | start no earlier than 2024-09-28 | 103/8/2 | 104/1/5 |
| 34 | 1.3.3.3 | Deliver to Vendor ShopNozzle Pipe/Transition Nozzle | 20d | 2025-03-25 | 2025-04-20 | 33 |  | 43d |  |  | 104/1/5 | 104/1/31 |
| 35 | 1.3.4 | **Plug -Plug Gasket** | 160d | 2024-09-29 | 2025-04-20 |  |  | 47d |  |  | 103/7/8 | 104/1/31 |
| 36 | 1.3.4.1 | Po Placement for Plug -Plug Gasket | 20d | 2024-09-29 | 2024-10-23 | 13SS+60d |  | 47d | 0d | start no earlier than 2024-09-28 | 103/7/8 | 103/8/2 |
| 37 | 1.3.4.2 | Fabrication for Plug -Plug Gasket | 120d | 2024-10-23 | 2025-03-25 | 36 |  | 47d | 0d | start no earlier than 2024-09-28 | 103/8/2 | 104/1/5 |
| 38 | 1.3.4.3 | Deliver to Vendor ShopPlug -Plug Gasket | 20d | 2025-03-25 | 2025-04-20 | 37 |  | 47d |  |  | 104/1/5 | 104/1/31 |
| 39 | 1.3.5 | **Core Tubes** | 160d | 2024-09-29 | 2025-04-20 |  |  | 24d |  |  | 103/7/8 | 104/1/31 |
| 40 | 1.3.5.1 | Po Placement for Core Tubes | 20d | 2024-09-29 | 2024-10-23 | 13SS+75d |  | 24d | 0d | start no earlier than 2024-09-28 | 103/7/8 | 103/8/2 |
| 41 | 1.3.5.2 | Fabrication for Core Tubes | 120d | 2024-10-23 | 2025-03-25 | 40 |  | 24d | 0d | start no earlier than 2024-09-28 | 103/8/2 | 104/1/5 |
| 42 | 1.3.5.3 | Deliver to Vendor ShopCore Tubes | 20d | 2025-03-25 | 2025-04-20 | 41 |  | 24d | 0d |  | 104/1/5 | 104/1/31 |
| 43 | 1.3.6 | **Al.Tubes** | 170d | 2024-06-01 A | 2025-01-01 A |  | 100% |  |  |  | 103/3/12 | 103/10/12 |
| 44 | 1.3.6.1 | Po Placement for Al.Tubes | 20d | 2024-06-01 A | 2024-06-25 A | 13SS+75d | 100% |  |  |  | 103/3/12 | 103/4/5 |
| 45 | 1.3.6.2 | Fabrication for Al.Tubes | 130d | 2024-06-25 A | 2024-12-08 A | 44 | 100% |  |  |  | 103/4/5 | 103/9/18 |
| 46 | 1.3.6.3 | Deliver to Vendor Shop Al.Tubes | 20d | 2024-12-08 A | 2025-01-01 A | 45 | 100% |  |  |  | 103/9/18 | 103/10/12 |
| 47 | 1.3.7 | **All Nut & Bolts** | 120d | 2024-09-29 | 2025-03-01 |  |  | 112d |  |  | 103/7/8 | 103/12/11 |
| 48 | 1.3.7.1 | Po Placement for All Nut & Bolts | 20d | 2024-09-29 | 2024-10-23 | 13SS+145d, 15SS+115d |  | 112d | 0d | start no earlier than 2024-09-28 | 103/7/8 | 103/8/2 |
| 49 | 1.3.7.2 | Fabrication for All Nut & Bolts | 80d | 2024-10-23 | 2025-02-02 | 48 |  | 112d | 0d | start no earlier than 2024-09-28 | 103/8/2 | 103/11/14 |
| 50 | 1.3.7.3 | Deliver to Vendor ShopAll Nut & Bolts | 20d | 2025-02-02 | 2025-03-01 | 49 |  | 112d | 95.8d |  | 103/11/14 | 103/12/11 |

| ID | WBS | Task | Duration | Start | Finish | Predecessors | Total slack | Free slack | Constraint | Start Date | Finish Date |
| --- | --- | --- | --- | --- | --- | --- | --- | --- | --- | --- | --- |
| 51 | 1.3.8 | **Stud Bolt** | 120d | 2025-01-28 | 2025-06-29 |  | 15.2d |  |  | 103/11/9 | 104/4/8 |
| 52 | 1.3.8.1 | Po Placement for Stud Bolt | 20d | 2025-01-28 | 2025-02-23 | 13FS-40d | 15.2d | 0d |  | 103/11/9 | 103/12/5 |
| 53 | 1.3.8.2 | Fabrication for Stud Bolt | 80d | 2025-02-23 | 2025-06-03 | 52 | 15.2d | 0d |  | 103/12/5 | 104/3/13 |
| 54 | 1.3.8.3 | Deliver to Vendor ShopStud Bolt | 20d | 2025-06-03 | 2025-06-29 | 53 | 15.2d |  |  | 104/3/13 | 104/4/8 |
| 55 | 1.3.9 | **Plate - Profile for Side Frame** | 100d | 2024-12-21 | 2025-04-27 |  | 12.2d |  |  | 103/10/1 | 104/2/7 |
| 56 | 1.3.9.1 | Po Placement for Plate - Profile for Side Frame | 20d | 2024-12-21 | 2025-01-14 | 13FS-70d | 12.2d | 0d | start no earlier than 2024-09-28 | 103/10/1 | 103/10/25 |
| 57 | 1.3.9.2 | Fabrication for Plate - Profile for Side Frame | 60d | 2025-01-14 | 2025-04-01 | 56 | 12.2d | 0d |  | 103/10/25 | 104/1/12 |
| 58 | 1.3.9.3 | Deliver to Vendor ShopPlate - Profile for Side Frame | 20d | 2025-04-01 | 2025-04-27 | 57 | 12.2d | 0d |  | 104/1/12 | 104/2/7 |
| 59 | 1.3.10 | **Bearing Block** | 110d | 2025-02-10 | 2025-06-29 |  | 6.2d |  |  | 103/11/22 | 104/4/8 |
| 60 | 1.3.10.1 | Po Placement for Bearing Block | 20d | 2025-02-10 | 2025-03-08 | 13FS-30d | 6.2d | 0d |  | 103/11/22 | 103/12/18 |
| 61 | 1.3.10.2 | Fabrication for Bearing Block | 70d | 2025-03-08 | 2025-06-03 | 60 | 6.2d | 0d |  | 103/12/18 | 104/3/13 |
| 62 | 1.3.10.3 | Deliver to Vendor ShopBearing Block | 20d | 2025-06-03 | 2025-06-29 | 61 | 6.2d | 0d |  | 104/3/13 | 104/4/8 |
| 63 | 1.3.11 | **Steel Structure & Fan & Motor Support** | 110d | 2025-01-14 | 2025-06-03 |  | 16.2d |  |  | 103/10/25 | 104/3/13 |
| 64 | 1.3.11.1 | Po Placement for Steel Structure & Fan & Motor Support | 20d | 2025-01-14 | 2025-02-10 | 13FS-50d, 15FS-50d | 16.2d | 0d |  | 103/10/25 | 103/11/22 |
| 65 | 1.3.11.2 | Fabrication for Steel Structure & Fan & Motor Support | 80d | 2025-02-10 | 2025-05-21 | 64 | 16.2d | 0d |  | 103/11/22 | 104/2/31 |
| 66 | 1.3.11.3 | Deliver to Vendor ShopSteel Structure & Fan & Motor Support | 10d | 2025-05-21 | 2025-06-03 | 65 | 16.2d | 0d |  | 104/2/31 | 104/3/13 |
| 67 | 1.3.12 | **Grating & Grating Clamps** | 70d | 2025-03-19 | 2025-06-17 |  | 16.2d |  |  | 103/12/29 | 104/3/27 |
| 68 | 1.3.12.1 | Po Placement for Grating & Grating Clamps | 10d | 2025-03-19 | 2025-04-01 | 13, 15 | 16.2d | 0d |  | 103/12/29 | 104/1/12 |
| 69 | 1.3.12.2 | Fabrication for Grating & Grating Clamps | 50d | 2025-04-01 | 2025-06-03 | 68 | 16.2d | 0d |  | 104/1/12 | 104/3/13 |
| 70 | 1.3.12.3 | Deliver to Vendor ShopGrating & Grating Clamps | 10d | 2025-06-03 | 2025-06-17 | 69 | 16.2d | 10d |  | 104/3/13 | 104/3/27 |
| 71 | 1.3.13 | **Fan Ring & Plenum** | 110d | 2025-02-10 | 2025-06-29 |  | 11.2d |  |  | 103/11/22 | 104/4/8 |
| 72 | 1.3.13.1 | Po Placement for Fan Ring & Plenum | 20d | 2025-02-10 | 2025-03-08 | 13FS-30d | 11.2d | 0d |  | 103/11/22 | 103/12/18 |
| 73 | 1.3.13.2 | Fabrication for Fan Ring & Plenum | 70d | 2025-03-08 | 2025-06-03 | 72 | 11.2d | 0d |  | 103/12/18 | 104/3/13 |
| 74 | 1.3.13.3 | Deliver to Vendor Shop Fan Ring & Plenum | 20d | 2025-06-03 | 2025-06-29 | 73 | 11.2d | 0d |  | 104/3/13 | 104/4/8 |

| ID | WBS | Task | Duration | Start | Finish | Predecessors | Total slack | Free slack | Start Date | Finish Date |
| --- | --- | --- | --- | --- | --- | --- | --- | --- | --- | --- |
| 75 | 1.3.14 | **Louver** | 110d | 2025-01-28 | 2025-06-17 |  | 16.2d |  | 103/11/9 | 104/3/27 |
| 76 | 1.3.14.1 | Po Placement for Louver | 20d | 2025-01-28 | 2025-02-23 | 13FS-40d | 16.2d | 0d | 103/11/9 | 103/12/5 |
| 77 | 1.3.14.2 | Fabrication for Louver | 70d | 2025-02-23 | 2025-05-21 | 76 | 16.2d | 0d | 103/12/5 | 104/2/31 |
| 78 | 1.3.14.3 | Deliver to Vendor Shop Louver | 20d | 2025-05-21 | 2025-06-17 | 77 | 16.2d | 10d | 104/2/31 | 104/3/27 |
| 79 | 1.3.15 | **Fan Guard & Pully Guard** | 110d | 2025-02-10 | 2025-06-29 |  | 11.2d |  | 103/11/22 | 104/4/8 |
| 80 | 1.3.15.1 | Po Placement for Fan Guard & Pully Guard | 20d | 2025-02-10 | 2025-03-08 | 13FS-30d | 11.2d | 0d | 103/11/22 | 103/12/18 |
| 81 | 1.3.15.2 | Fabrication for Fan Guard & Pully Guard | 70d | 2025-03-08 | 2025-06-03 | 80 | 11.2d | 0d | 103/12/18 | 104/3/13 |
| 82 | 1.3.15.3 | Deliver to Vendor Shop Fan Guard & Pully Guard | 20d | 2025-06-03 | 2025-06-29 | 81 | 11.2d | 0d | 104/3/13 | 104/4/8 |
| 83 | 1.3.16 | **I/P Convertor** | 160d | 2025-01-08 | 2025-07-30 |  | 6d |  | 103/10/19 | 104/5/8 |
| 84 | 1.3.16.1 | Inquiry for I/P Convertor | 20d | 2025-01-08 | 2025-02-03 | 14 | 6d | 0d | 103/10/19 | 103/11/15 |
| 85 | 1.3.16.2 | Po Placement for I/P Convertor | 20d | 2025-02-03 | 2025-03-01 | 84 | 6d | 0d | 103/11/15 | 103/12/11 |
| 86 | 1.3.16.3 | Fabrication for I/P Convertor | 70d | 2025-03-02 | 2025-05-28 | 85 | 6d | 0d | 103/12/12 | 104/3/7 |
| 87 | 1.3.16.4 | Shipping for I/P Convertor | 20d | 2025-05-28 | 2025-06-22 | 86 | 6d | 0d | 104/3/7 | 104/4/1 |
| 88 | 1.3.16.5 | Custom Clearance for I/P Convertor | 20d | 2025-06-22 | 2025-07-19 | 87 | 6d | 0d | 104/4/1 | 104/4/28 |
| 89 | 1.3.16.6 | Deliver to Vendor Shop I/P Convertor | 10d | 2025-07-19 | 2025-07-30 | 88 | 6d | 0d | 104/4/28 | 104/5/8 |
| 90 | 1.3.17 | **Motor** | 160d | 2025-01-08 | 2025-07-30 |  | 6d |  | 103/10/19 | 104/5/8 |
| 91 | 1.3.17.1 | Inquiry for Motor | 20d | 2025-01-08 | 2025-02-03 | 14 | 6d | 0d | 103/10/19 | 103/11/15 |
| 92 | 1.3.17.2 | Po Placement for Motor | 20d | 2025-02-03 | 2025-03-01 | 91 | 6d | 0d | 103/11/15 | 103/12/11 |
| 93 | 1.3.17.3 | Fabrication for Motor | 70d | 2025-03-02 | 2025-05-28 | 92 | 6d | 0d | 103/12/12 | 104/3/7 |
| 94 | 1.3.17.4 | Shipping for Motor | 20d | 2025-05-28 | 2025-06-22 | 93 | 6d | 0d | 104/3/7 | 104/4/1 |
| 95 | 1.3.17.5 | Custom Clearance for Motor | 20d | 2025-06-22 | 2025-07-19 | 94 | 6d | 0d | 104/4/1 | 104/4/28 |
| 96 | 1.3.17.6 | Deliver to Vendor Shop Motor | 10d | 2025-07-19 | 2025-07-30 | 95 | 6d | 0d | 104/4/28 | 104/5/8 |
| 97 | 1.3.18 | **Vibration Switch** | 160d | 2025-01-08 | 2025-07-30 |  | 6d |  | 103/10/19 | 104/5/8 |
| 98 | 1.3.18.1 | Inquiry for Vibration Switch | 20d | 2025-01-08 | 2025-02-03 | 14 | 6d | 0d | 103/10/19 | 103/11/15 |
| 99 | 1.3.18.2 | Po Placement for Vibration Switch | 20d | 2025-02-03 | 2025-03-01 | 98 | 6d | 0d | 103/11/15 | 103/12/11 |
| 100 | 1.3.18.3 | Fabrication for Vibration Switch | 80d | 2025-03-02 | 2025-06-10 | 99 | 6d | 0d | 103/12/12 | 104/3/20 |
| 101 | 1.3.18.4 | Shipping for Vibration Switch | 20d | 2025-06-10 | 2025-07-05 | 100 | 6d | 0d | 104/3/20 | 104/4/14 |
| 102 | 1.3.18.5 | Custom Clearance for Vibration Switch | 10d | 2025-07-06 | 2025-07-19 | 101 | 6d | 0d | 104/4/15 | 104/4/28 |
| 103 | 1.3.18.6 | Deliver to Vendor Shop Vibration Switch | 10d | 2025-07-19 | 2025-07-30 | 102 | 6d | 0d | 104/4/28 | 104/5/8 |

| ID | WBS | Task | Duration | Start | Finish | Predecessors | Total slack | Free slack | Constraint | Start Date | Finish Date |
| --- | --- | --- | --- | --- | --- | --- | --- | --- | --- | --- | --- |
| 104 | 1.3.19 | **Fan** | 150d | 2025-01-14 | 2025-07-23 |  | 11.2d |  |  | 103/10/25 | 104/5/1 |
| 105 | 1.3.19.1 | Inquiry for Fan | 20d | 2025-01-14 | 2025-02-10 | 13FS-50d | 11.2d | 0d | start no earlier than 2024-07-06 | 103/10/25 | 103/11/22 |
| 106 | 1.3.19.2 | Po Placement for Fan | 20d | 2025-02-10 | 2025-03-08 | 105 | 11.2d | 0d |  | 103/11/22 | 103/12/18 |
| 107 | 1.3.19.3 | Fabrication for Fan | 50d | 2025-03-08 | 2025-05-10 | 106 | 11.2d | 0d |  | 103/12/18 | 104/2/20 |
| 108 | 1.3.19.4 | Shipping for Fan | 30d | 2025-05-10 | 2025-06-17 | 107 | 11.2d | 0d |  | 104/2/20 | 104/3/27 |
| 109 | 1.3.19.5 | Custom Clearance for Fan | 20d | 2025-06-17 | 2025-07-12 | 108 | 11.2d | 0d |  | 104/3/27 | 104/4/21 |
| 110 | 1.3.19.6 | Deliver to Vendor Shop Fan | 10d | 2025-07-12 | 2025-07-23 | 109 | 11.2d | 5.2d |  | 104/4/21 | 104/5/1 |
| 111 | 1.3.20 | **Bellt & Pully** | 120d | 2025-02-23 | 2025-07-23 |  | 11.2d |  |  | 103/12/5 | 104/5/1 |
| 112 | 1.3.20.1 | Inquiry for Bellt & Pully | 20d | 2025-02-23 | 2025-03-19 | 13FS-20d | 11.2d | 0d |  | 103/12/5 | 103/12/29 |
| 113 | 1.3.20.2 | Po Placement for Bellt & Pully | 10d | 2025-03-19 | 2025-04-01 | 112 | 11.2d | 0d |  | 103/12/29 | 104/1/12 |
| 114 | 1.3.20.3 | Fabrication for Bellt & Pully | 50d | 2025-04-01 | 2025-06-03 | 113 | 11.2d | 0d |  | 104/1/12 | 104/3/13 |
| 115 | 1.3.20.4 | Shipping for Bellt & Pully | 20d | 2025-06-03 | 2025-06-29 | 114 | 11.2d | 0d |  | 104/3/13 | 104/4/8 |
| 116 | 1.3.20.5 | Custom Clearance for Bellt & Pully | 10d | 2025-06-29 | 2025-07-12 | 115 | 11.2d | 0d |  | 104/4/8 | 104/4/21 |
| 117 | 1.3.20.6 | Deliver to Vendor Shop Bellt & Pully | 10d | 2025-07-12 | 2025-07-23 | 116 | 11.2d | 5.2d |  | 104/4/21 | 104/5/1 |
| 118 | 1.4 | **Manufacturing** | 70.2d | 2025-04-27 | 2025-07-23 |  | 10d |  |  | 104/2/7 | 104/5/1 |
| 119 | 1.4.1 | **Air Cooler Tag No. AE-2101 (A / B / C)** | 70.2d | 2025-04-27 | 2025-07-23 |  | 0d |  |  | 104/2/7 | 104/5/1 |
| 120 | 1.4.1.1 | **Fabrication Of Header Box** | 33d | 2025-06-14 | 2025-07-23 |  | 0d |  |  | 104/3/24 | 104/5/1 |
| 121 | 1.4.1.1.1 | Cutting | 6d | 2025-06-14 | 2025-06-21 | 26, 34 | 0d |  |  | 104/3/24 | 104/3/31 |
| 122 | 1.4.1.1.2 | Assembly | 6d | 2025-06-18 | 2025-06-24 | 121FS-2d, 26 | 0d |  |  | 104/3/28 | 104/4/3 |
| 123 | 1.4.1.1.3 | Welding | 6d | 2025-06-22 | 2025-06-30 | 122FS-2d, 30 | 0d |  |  | 104/4/1 | 104/4/9 |
| 124 | 1.4.1.1.4 | CNC | 5d | 2025-06-28 | 2025-07-05 | 123FS-2d | 0d |  |  | 104/4/7 | 104/4/14 |
| 125 | 1.4.1.1.5 | Nozzle & Flang Assembly | 5d | 2025-07-01 | 2025-07-07 | 124FS-2d | 0d |  |  | 104/4/10 | 104/4/16 |
| 126 | 1.4.1.1.6 | Final Machining | 5d | 2025-07-06 | 2025-07-12 | 125FS-2d | 0d |  |  | 104/4/15 | 104/4/21 |
| 127 | 1.4.1.1.7 | Coating | 5d | 2025-07-08 | 2025-07-15 | 126FS-2d | 0d |  |  | 104/4/17 | 104/4/24 |
| 128 | 1.4.1.1.8 | Assembly / test of Tube Bundle | 7d | 2025-07-15 | 2025-07-23 | 127, 133, 135 | 0d |  |  | 104/4/24 | 104/5/1 |

| ID | WBS | Task | Duration | Start | Finish | Predecessors | Total slack | Free slack | Start Date | Finish Date |
| --- | --- | --- | --- | --- | --- | --- | --- | --- | --- | --- |
| 129 | 1.4.1.2 | **Fabrication Of Bundle Frame** | 50d | 2025-04-27 | 2025-06-29 |  | 13.2d |  | 104/2/7 | 104/4/8 |
| 130 | 1.4.1.2.1 | Cutting | 10d | 2025-04-27 | 2025-05-10 | 58 | 13.2d | 0d | 104/2/7 | 104/2/20 |
| 131 | 1.4.1.2.2 | Assembly | 10d | 2025-05-17 | 2025-05-28 | 130FS+5d | 13.2d | 0d | 104/2/27 | 104/3/7 |
| 132 | 1.4.1.2.3 | Welding | 10d | 2025-06-03 | 2025-06-17 | 131FS+5d | 13.2d | 0d | 104/3/13 | 104/3/27 |
| 133 | 1.4.1.2.4 | Coating | 10d | 2025-06-17 | 2025-06-29 | 132 | 13.2d |  | 104/3/27 | 104/4/8 |
| 134 | 1.4.1.3 | **Fabrication Of Fin Tube** | 25d | 2025-05-14 | 2025-06-16 |  | 24d |  | 104/2/24 | 104/3/26 |
| 135 | 1.4.1.3.1 | Fabrication Of Fin Tube | 25d | 2025-05-14 | 2025-06-16 | 42FS+20d, 46FS+20d | 24d |  | 104/2/24 | 104/3/26 |
| 136 | 1.4.2 | **Air Cooler Tag No. AE-2102 (A / B / C)** | 56d | 2025-05-14 | 2025-07-23 |  | 10d |  | 104/2/24 | 104/5/1 |
| 137 | 1.4.2.1 | **Fabrication Of Header Box** | 33d | 2025-06-14 | 2025-07-23 |  | 0d |  | 104/3/24 | 104/5/1 |
| 138 | 1.4.2.1.1 | Cutting | 6d | 2025-06-14 | 2025-06-21 | 26, 34 | 0d |  | 104/3/24 | 104/3/31 |
| 139 | 1.4.2.1.2 | Assembly | 6d | 2025-06-18 | 2025-06-24 | 121FS-2d, 26, 38, 138FS-2d | 0d |  | 104/3/28 | 104/4/3 |
| 140 | 1.4.2.1.3 | Welding | 6d | 2025-06-22 | 2025-06-30 | 122FS-2d, 139FS-2d | 0d |  | 104/4/1 | 104/4/9 |
| 141 | 1.4.2.1.4 | CNC | 6d | 2025-06-28 | 2025-07-05 | 123FS-2d, 140FS-2d | 0d |  | 104/4/7 | 104/4/14 |
| 142 | 1.4.2.1.5 | Nozzle & Flang Assembly | 6d | 2025-07-02 | 2025-07-09 | 124FS-2d, 141FS-2d | 0d |  | 104/4/11 | 104/4/18 |
| 143 | 1.4.2.1.6 | Final Machining | 5d | 2025-07-07 | 2025-07-14 | 125FS-2d, 142FS-2d | 0d |  | 104/4/16 | 104/4/23 |
| 144 | 1.4.2.1.7 | Coating | 5d | 2025-07-12 | 2025-07-19 | 126FS-2d, 143FS-2d | 0d |  | 104/4/21 | 104/4/28 |
| 145 | 1.4.2.1.8 | Assembly /test of Tube Bundle | 5d | 2025-07-19 | 2025-07-23 | 127, 54, 133, 135SS, 144, 150, 152SS+10d | 0d |  | 104/4/28 | 104/5/1 |
| 146 | 1.4.2.2 | **Fabrication Of Bundle Frame** | 23d | 2025-06-03 | 2025-07-01 |  | 12.2d |  | 104/3/13 | 104/4/10 |
| 147 | 1.4.2.2.1 | Cutting | 5d | 2025-06-03 | 2025-06-10 | 58FS+30d | 12.2d | 0d | 104/3/13 | 104/3/20 |
| 148 | 1.4.2.2.2 | Assembly | 5d | 2025-06-10 | 2025-06-17 | 147 | 12.2d | 0d | 104/3/20 | 104/3/27 |
| 149 | 1.4.2.2.3 | Welding | 5d | 2025-06-17 | 2025-06-22 | 148 | 12.2d | 0d | 104/3/27 | 104/4/1 |
| 150 | 1.4.2.2.4 | Coating | 8d | 2025-06-22 | 2025-07-01 | 149 | 12.2d |  | 104/4/1 | 104/4/10 |
| 151 | 1.4.2.3 | **Fabrication Of Fin Tube** | 25d | 2025-05-14 | 2025-06-16 |  | 41d |  | 104/2/24 | 104/3/26 |
| 152 | 1.4.2.3.1 | Fabrication Of Fin Tube | 25d | 2025-05-14 | 2025-06-16 | 42FS+20d, 46FS+20d | 41d |  | 104/2/24 | 104/3/26 |

| ID | WBS | Task | Duration | Start | Finish | Predecessors | Total slack | Free slack | Start Date | Finish Date |
| --- | --- | --- | --- | --- | --- | --- | --- | --- | --- | --- |
| 153 | 1.5 | **Inspection / Delivery** | 56.2d | 2025-06-03 | 2025-08-13 |  | 0d |  | 104/3/13 | 104/5/22 |
| 154 | 1.5.1 | **Air Cooler Tag No. AE-2101 (A / B / C)** | 56.2d | 2025-06-03 | 2025-08-13 |  | 0d |  | 104/3/13 | 104/5/22 |
| 155 | 1.5.1.1 | Tube Bundle | 15d | 2025-07-26 | 2025-08-13 | 128FS+1d, 145FS+1d | 0d |  | 104/5/4 | 104/5/22 |
| 156 | 1.5.1.2 | Steel Structure & MOT | 20d | 2025-06-03 | 2025-06-29 | 66 | 16.2d | 0d | 104/3/13 | 104/4/8 |
| 157 | 1.5.1.3 | Accessories | 15d | 2025-06-29 | 2025-07-16 | 82, 74, 62, 70, 78 | 21.2d | 10.2d | 104/4/8 | 104/4/25 |
| 158 | 1.5.1.4 | Equipment | 5d | 2025-07-30 | 2025-08-05 | 117, 110, 103, 96, 89 | 6d | 0d | 104/5/8 | 104/5/14 |
| 159 | 1.5.2 | **Air Cooler Tag No. AE-2102 (A / B / C)** | 36.2d | 2025-06-29 | 2025-08-13 |  | 0d |  | 104/4/8 | 104/5/22 |
| 160 | 1.5.2.1 | Tube Bundle | 15d | 2025-07-26 | 2025-08-13 | 128FS+1d, 145FS+1d | 0d |  | 104/5/4 | 104/5/22 |
| 161 | 1.5.2.2 | Steel Structure & MOT | 20d | 2025-06-29 | 2025-07-23 | 156, 50 | 16.2d |  | 104/4/8 | 104/5/1 |
| 162 | 1.5.2.3 | Accessories | 15d | 2025-07-16 | 2025-08-05 | 82FS+10d, 74FS+10d, 62FS+15d, 70FS+15d, 78FS+15d, 66FS+15d | 6.2d |  | 104/4/25 | 104/5/14 |
| 163 | 1.5.2.4 | Equipment | 5d | 2025-07-30 | 2025-08-05 | 117, 110, 103, 96, 89 | 6d | 0d | 104/5/8 | 104/5/14 |
| 164 | 1.6 | **Final book** | 6d | 2025-08-05 | 2025-08-13 |  | 0d |  | 104/5/14 | 104/5/22 |
| 165 | 1.6.1 | Final Data Book Index for Air Coolers | 6d | 2025-08-05 | 2025-08-13 | 158FF, 163FF, 160FF | 0d |  | 104/5/14 | 104/5/22 |
| 166 | 1.6.2 | Final Data Book for Air Coolers | 6d | 2025-08-05 | 2025-08-13 | 165SS | 0d |  | 104/5/14 | 104/5/22 |
